# Cronograma buque Sonora 09.04.2008

Schedule from MS Project, 2008-03-25 to 2008-10-24.
Siemens AG

## Calendars

- Standard: Mon-Fri 08:00-12:00, 13:00-17:00; Sat-Sun off.

## Resources

| Resource |
| --- |
| Astillero |

## Schedule

| ID | WBS | Task | Duration | Start | Finish | Predecessors | Total slack | Free slack | Constraint | Resources | Work |
| --- | --- | --- | --- | --- | --- | --- | --- | --- | --- | --- | --- |
| 1 | 1 | **Inicio** | 1d | 2008-03-25 | 2008-03-25 |  | 137d |  |  |  |  |
| 2 | 1.1 | Presentación del Plan de Trabajo y del Equipo de Trabajo con el Astillero | 1d | 2008-03-25 | 2008-03-25 |  | 137d | 5d | start no earlier than 2008-03-25 |  |  |
| 3 | 2 | **Tablero 2S** | 45d? | 2008-03-31 | 2008-05-30 |  | 105d |  |  |  | 40h |
| 4 | 2.1 | Entrega de Material | 4w | 2008-04-14 | 2008-05-09 |  | 120d |  | start no earlier than 2008-04-14 |  |  |
| 5 | 2.2 | Desinstalación de equipos | 2d | 2008-04-01 | 2008-04-02 | 2SS | 132d | 0d | start no earlier than 2008-04-01 |  |  |
| 6 | 2.3 | Desmontaje de puertas | 2d | 2008-04-01 | 2008-04-02 | 5SS | 132d | 2d | start no earlier than 2008-04-01 |  |  |
| 7 | 2.4 | Fabricación de Puertas | 3w | 2008-04-07 | 2008-04-25 | 6 | 130d |  | start no earlier than 2008-04-07 |  |  |
| 8 | 2.5 | Identificación de cables de fuerza | 2d | 2008-03-31 | 2008-04-01 |  | 148d | 0d | start no earlier than 2008-03-31 |  |  |
| 9 | 2.6 | Verificación de cables en mal estado | 3d | 2008-04-23 | 2008-04-25 |  | 130d |  | start no earlier than 2008-04-23 |  |  |
| 10 | 2.7 | Verificación de capacidad de barras | 1d | 2008-03-31 | 2008-03-31 | 8SS | 149d |  |  |  |  |
| 11 | 2.8 | Suministro de material para el bus | 3d | 2008-04-23 | 2008-04-25 |  | 128d | 0d | start no earlier than 2008-04-23 |  |  |
| 12 | 2.9 | Modificar del Bus de Tablero 2S Instalando barra de cobre de 3 X 1/4 | 2d | 2008-04-28 | 2008-04-29 | 11 | 128d |  | start no earlier than 2008-04-07 |  |  |
| 13 | 2.10 | Identificación de Cables de Control y Cedula de Cableado | 2d | 2008-04-23 | 2008-04-24 |  | 131d |  | start no earlier than 2008-04-23 |  |  |
| 14 | 2.11 | Instalación de Clemas y canaleta en la placa de Montaje | 2w | 2008-04-28 | 2008-05-09 |  | 115d | 0d | start no earlier than 2008-04-28 |  |  |
| 15 | 2.12 | Prepara Arneces en puerta de Gen 3, Gen 2 y Enlace | 2w | 2008-04-28 | 2008-05-09 | 14SS | 115d | 0d |  |  |  |
| 16 | 2.13 | Instalación de Interruptores electromagneticos. | 2d | 2008-05-12 | 2008-05-13 | 15 | 115d | 0d |  |  |  |
| 17 | 2.14 | Conexión de electros a Bus | 3d | 2008-05-14 | 2008-05-16 | 16 | 115d |  |  |  |  |
| 18 | 2.15 | Instalación de equipos en puertas | 1w | 2008-05-12 | 2008-05-16 |  | 105d | 0d | start no earlier than 2008-05-12 |  |  |
| 19 | 2.16 | Montaje de equipos en celdas de control G2 | 2w | 2008-05-19 | 2008-05-30 | 18 | 105d | 0d |  |  |  |
| 20 | 2.17 | Montaje de equipos en celdas de control G3 | 2w | 2008-05-19 | 2008-05-30 | 19SS | 105d | 0d |  |  |  |
| 21 | 2.18 | Montaje de equipos en celdas de control Enlace 2 | 2w | 2008-05-19 | 2008-05-30 | 20SS | 105d |  |  |  |  |
| 22 | 2.19 | Alambrado de celda de G2 | 1w | 2008-05-26 | 2008-05-30 |  | 105d | 0d | start no earlier than 2008-05-26 |  |  |
| 23 | 2.20 | Alambrado de celda de G3 | 1w | 2008-05-26 | 2008-05-30 | 22SS | 105d | 0d |  |  |  |
| 24 | 2.21 | Alambrado de celda Enlace 2 | 1w | 2008-05-26 | 2008-05-30 | 23SS | 105d | 2d |  |  |  |
| 25 | 2.22 | Puesta en Marcha 2S | 3d | 2008-05-28 | 2008-05-30 | 24SS | 105d |  | start no earlier than 2008-05-28 |  |  |
| 26 | 2.23 | Entrega de Trayectorias de Cableado | 1d? | 2008-04-11 | 2008-04-11 |  | 135d | 15d | start no earlier than 2008-04-11 |  |  |
| 27 | 2.24 | Tendido de trayectorias de Cableado | 1w | 2008-05-05 | 2008-05-09 | 26 | 120d |  | start no earlier than 2008-05-05 | Astillero | 40h |

| ID | WBS | Task | Duration | Start | Finish | Predecessors | Total slack | Free slack | Constraint | Resources | Work |
| --- | --- | --- | --- | --- | --- | --- | --- | --- | --- | --- | --- |
| 28 | 3 | **Tablero 1S** | 77d | 2008-04-03 | 2008-07-18 |  | 70d |  |  |  | 120h |
| 29 | 3.1 | Entrega de Material | 9w | 2008-04-14 | 2008-06-13 |  | 75d | 0d | start no earlier than 2008-04-14 |  |  |
| 30 | 3.2 | Desinstalación de equipos | 2d | 2008-04-03 | 2008-04-04 |  | 140d | 0d | start no earlier than 2008-04-03 |  |  |
| 31 | 3.3 | Desmontaje de tablero existente | 1w | 2008-04-07 | 2008-04-11 | 30 | 140d |  |  | Astillero | 40h |
| 32 | 3.4 | Identificación de cables de fuerza | 2d | 2008-04-03 | 2008-04-04 | 30SS | 145d | 14d |  |  |  |
| 33 | 3.5 | Identificación de cables de control. | 2d | 2008-04-23 | 2008-04-24 | 32SS | 131d | 0d | start no earlier than 2008-04-23 |  |  |
| 34 | 3.6 | Verificación de cables en mal estado | 2d | 2008-04-23 | 2008-04-24 | 33SS | 131d |  | start no earlier than 2008-04-01 |  |  |
| 35 | 3.7 | Elaboración de Cedula de Cableado | 1w | 2008-04-21 | 2008-04-25 |  | 130d |  | start no earlier than 2008-04-21 |  |  |
| 36 | 3.8 | Montaje del Tablero 1S Nuevo. | 1w | 2008-06-16 | 2008-06-20 | 29 | 75d | 0d | start no earlier than 2008-06-16 | Astillero | 40h |
| 37 | 3.9 | Armado de celda G1 | 3w | 2008-06-23 | 2008-07-11 | 36 | 75d | 0d |  |  |  |
| 38 | 3.10 | Armado de celda Enlace | 3w | 2008-06-23 | 2008-07-11 | 37SS | 75d | 0d |  |  |  |
| 39 | 3.11 | Armado de celda SL | 3w | 2008-06-23 | 2008-07-11 | 38SS | 75d | 0d |  |  |  |
| 40 | 3.12 | Armado de celdas de distribución | 3w | 2008-06-23 | 2008-07-11 | 39SS | 75d |  |  |  |  |
| 41 | 3.13 | Armado del Bus de Cobre | 1w | 2008-07-07 | 2008-07-11 |  | 75d |  | start no earlier than 2008-07-07 |  |  |
| 42 | 3.14 | Alambrado de celda a G1 | 1w | 2008-07-07 | 2008-07-11 |  | 65d | 0d | start no earlier than 2008-07-07 |  |  |
| 43 | 3.15 | Alambrado de celda a SL | 1w | 2008-07-07 | 2008-07-11 | 42SS | 75d |  | start no earlier than 2008-06-30 |  |  |
| 44 | 3.16 | Alambrado de celda Enlace 1 a Enlace 2 | 1w | 2008-07-07 | 2008-07-11 | 42SS | 65d | 0d | start no earlier than 2008-06-30 |  |  |
| 45 | 3.17 | Puesta en Marcha 1S | 1w | 2008-07-14 | 2008-07-18 | 44 | 65d | 0d |  |  |  |
| 46 | 3.18 | Entrega de Trayectorias de Cableado | 1d | 2008-04-11 | 2008-04-11 |  | 135d | 20d | start no earlier than 2008-04-11 |  |  |
| 47 | 3.19 | Tendido de trayectorias de Cableado | 1w | 2008-05-12 | 2008-05-16 | 46 | 115d |  | start no earlier than 2008-05-12 | Astillero | 40h |
| 48 | 4 | **Consolas Cuarto de Control** | 149d | 2008-03-25 | 2008-10-17 |  | 5d |  |  |  | 136h |
| 49 | 4.1 | Suministro de Material | 9w | 2008-04-14 | 2008-06-13 |  | 65d | 0d | start no earlier than 2008-04-14 |  |  |
| 50 | 4.2 | Desinstalación de equipos | 2d | 2008-03-25 | 2008-03-26 |  | 147d | 21d | start no earlier than 2008-03-25 |  |  |
| 51 | 4.3 | Identificación de cables de control. | 2d | 2008-04-23 | 2008-04-24 | 50SS | 126d | 0d | start no earlier than 2008-04-23 |  |  |
| 52 | 4.4 | Elaborar Cedula de Cableado | 1w | 2008-04-25 | 2008-05-01 | 51 | 126d |  | start no earlier than 2008-04-21 |  |  |
| 53 | 4.5 | Verificación del estado fisico de los cables | 2d | 2008-04-23 | 2008-04-24 | 50SS | 131d |  | start no earlier than 2008-04-23 |  |  |
| 54 | 4.6 | Desmontaje de la Consola de Control | 2d | 2008-04-07 | 2008-04-08 |  | 143d |  | start no earlier than 2008-04-07 | Astillero | 16h |
| 55 | 4.7 | Aramado de Consolas PMA | 3w | 2008-06-16 | 2008-07-04 | 49 | 65d | 0d |  |  |  |
| 56 | 4.8 | Aramado de Consolas IMAC | 3w | 2008-06-16 | 2008-07-04 | 55SS | 65d | 0d |  |  |  |
| 57 | 4.9 | Aramado de Consolas MEC | 1w | 2008-10-13 | 2008-10-17 |  | 5d |  | start no earlier than 2008-10-13 |  |  |
| 58 | 4.10 | Instalación de Consolas | 1w | 2008-06-23 | 2008-06-27 |  | 70d | 0d | start no earlier than 2008-06-23 | Astillero | 40h |
| 59 | 4.11 | Puesta en Marcha IMAC | 3w | 2008-06-30 | 2008-07-18 | 58 | 70d |  |  |  |  |
| 60 | 4.12 | Puesta en Marcha PMA | 1w | 2008-07-21 | 2008-07-25 | 45 | 65d |  | start no earlier than 2008-07-14 |  |  |
| 61 | 4.13 | Entrega de Trayectorias de Cableado | 1d | 2008-04-11 | 2008-04-11 |  | 130d | 20d | start no earlier than 2008-04-11 |  |  |
| 62 | 4.14 | Tendido de trayectorias de Cableado | 2w | 2008-05-12 | 2008-05-23 | 61 | 110d |  | start no earlier than 2008-05-12 | Astillero | 80h |

| ID | WBS | Task | Duration | Start | Finish | Predecessors | Total slack | Free slack | Constraint | Resources | Work |
| --- | --- | --- | --- | --- | --- | --- | --- | --- | --- | --- | --- |
| 63 | 5 | **Consola Puente de Mando.** | 88d | 2008-03-26 | 2008-07-25 |  | 65d |  |  |  | 80h |
| 64 | 5.1 | Entrega de materiales | 9w | 2008-04-14 | 2008-06-13 |  | 75d | 0d | start no earlier than 2008-04-14 |  |  |
| 65 | 5.2 | Desinstalación de equipos | 1d | 2008-03-26 | 2008-03-26 |  | 152d |  | start no earlier than 2008-03-26 |  |  |
| 66 | 5.3 | Identificación de cables de control. | 2d | 2008-04-23 | 2008-04-24 |  | 131d | 0d | start no earlier than 2008-04-23 |  |  |
| 67 | 5.4 | Verificación del estado fisico de los cables | 2d | 2008-04-23 | 2008-04-24 | 66SS | 131d |  |  |  |  |
| 68 | 5.5 | Elaboración de Cedula de Cableado | 1w | 2008-04-21 | 2008-04-25 |  | 130d |  | start no earlier than 2008-04-21 |  |  |
| 69 | 5.6 | Desmontaje de placas frontales y placas pupitre | 1d | 2008-03-26 | 2008-03-26 |  | 152d |  | start no earlier than 2008-03-26 |  |  |
| 70 | 5.7 | Fabricación de nuevas placas con saques de equipos MEC | 1w | 2008-04-21 | 2008-04-25 |  | 130d |  | start no earlier than 2008-04-21 |  |  |
| 71 | 5.8 | Instalación de Equipos IMAC y MEC71 | 2w | 2008-06-16 | 2008-06-27 | 64 | 75d | 10d |  |  |  |
| 72 | 5.9 | Puesta en Marcha IMAC | 2w | 2008-07-14 | 2008-07-25 | 71 | 65d |  | start no earlier than 2008-07-14 |  |  |
| 73 | 5.10 | Entrega de Trayectorias de Cableado | 1d | 2008-04-11 | 2008-04-11 |  | 130d | 20d | start no earlier than 2008-04-11 |  |  |
| 74 | 5.11 | Tendido de trayectorias de Cableado | 2w | 2008-05-12 | 2008-05-23 | 73 | 110d |  | start no earlier than 2008-05-12 | Astillero | 80h |
| 75 | 6 | **Tablero Local de Estribor MP 377A** | 82d | 2008-03-27 | 2008-07-18 |  | 70d |  |  |  | 88h |
| 76 | 6.1 | Entrega de Material | 9w | 2008-04-14 | 2008-06-13 |  | 70d | 0d | start no earlier than 2008-04-14 |  |  |
| 77 | 6.2 | Desinstalación de equipos | 1d | 2008-03-27 | 2008-03-27 |  | 146d | 7d | start no earlier than 2008-03-27 |  |  |
| 78 | 6.3 | Desmontaje del Tablero | 1d | 2008-04-07 | 2008-04-07 | 77SS | 139d | 11d | start no earlier than 2008-04-07 | Astillero | 8h |
| 79 | 6.4 | Identificación de Cable y Cedula de Cableado | 2d | 2008-04-23 | 2008-04-24 | 78 | 128d | 3d | start no earlier than 2008-04-23 |  |  |
| 80 | 6.5 | Separación señales IMAC MEC | 1w | 2008-04-28 | 2008-05-02 | 79SS | 125d |  | start no earlier than 2008-04-28 |  |  |
| 81 | 6.6 | Armado de Tablero | 2w | 2008-06-16 | 2008-06-27 | 76 | 70d | 0d |  |  |  |
| 82 | 6.7 | Instalación de Tablero y conexión de señales | 2w | 2008-06-30 | 2008-07-11 | 81 | 70d | 0d | start no earlier than 2008-06-23 |  |  |
| 83 | 6.8 | Puesta En Marcha | 1w | 2008-07-14 | 2008-07-18 | 82 | 70d |  |  |  |  |
| 84 | 6.9 | Entrega de Trayectorias de Cableado | 1d | 2008-04-11 | 2008-04-11 |  | 130d | 25d | start no earlier than 2008-04-11 |  |  |
| 85 | 6.10 | Tendido de trayectorias de Cableado | 2w | 2008-05-19 | 2008-05-30 | 84 | 105d |  | start no earlier than 2008-05-19 | Astillero | 80h |
| 86 | 7 | **Tablero Loca deBabor MP 377A** | 81d | 2008-03-28 | 2008-07-18 |  | 70d |  |  |  | 96h |
| 87 | 7.1 | Entrega de Material | 9w | 2008-04-14 | 2008-06-13 |  | 70d | 0d | start no earlier than 2008-04-14 |  |  |
| 88 | 7.2 | Desinstalación de equipos | 2d | 2008-03-28 | 2008-03-31 |  | 149d |  | start no earlier than 2008-03-28 |  |  |
| 89 | 7.3 | Desmontaje del Tablero. | 2d | 2008-04-07 | 2008-04-08 |  | 143d |  | start no earlier than 2008-04-07 | Astillero | 16h |
| 90 | 7.4 | Identificación de Cable y Cedula de Cableado | 2d | 2008-04-23 | 2008-04-24 |  | 128d | 3d | start no earlier than 2008-04-23 |  |  |
| 91 | 7.5 | Separación señales IMAC MEC | 1w | 2008-04-28 | 2008-05-02 | 90SS | 125d |  | start no earlier than 2008-04-28 |  |  |
| 92 | 7.6 | Armado de Tablero | 2w | 2008-06-16 | 2008-06-27 | 87 | 70d | 0d |  |  |  |
| 93 | 7.7 | Instalación de Tablero y conexión de señales | 2w | 2008-06-30 | 2008-07-11 | 92 | 70d | 0d | start no earlier than 2008-06-23 |  |  |
| 94 | 7.8 | Puesta en Marcha | 1w | 2008-07-14 | 2008-07-18 | 93 | 70d |  |  |  |  |
| 95 | 7.9 | Entrega de Trayectorias de Cableado | 1d | 2008-04-11 | 2008-04-11 |  | 130d | 40d | start no earlier than 2008-04-11 |  |  |
| 96 | 7.10 | Tendido de trayectorias de Cableado | 2w | 2008-06-09 | 2008-06-20 | 95 | 90d |  | start no earlier than 2008-06-09 | Astillero | 80h |

| ID | WBS | Task | Duration | Start | Finish | Predecessors | Total slack | Free slack | Constraint | Resources | Work |
| --- | --- | --- | --- | --- | --- | --- | --- | --- | --- | --- | --- |
| 97 | 8 | **Tablero Local de Estribor MEC 71** | 145d? | 2008-04-07 | 2008-10-24 |  | 0d |  |  |  | 560h |
| 98 | 8.1 | Inspección en Sitio | 1w | 2008-04-21 | 2008-04-25 |  | 0d |  | start no earlier than 2008-04-21 |  |  |
| 99 | 8.2 | Aprovación de Planos | 4w | 2008-04-28 | 2008-05-23 | 98 | 0d |  |  |  |  |
| 100 | 8.3 | Fabricación de Equipo | 16w | 2008-05-26 | 2008-09-12 | 99 | 0d |  |  |  |  |
| 101 | 8.4 | Transportación a Guaymas | 4w | 2008-09-15 | 2008-10-10 | 100 | 0d |  |  |  |  |
| 102 | 8.5 | Instalación de Tablero y conexión de señales | 1w | 2008-10-13 | 2008-10-17 | 101 | 0d |  | start no earlier than 2008-09-15 |  |  |
| 103 | 8.6 | Puesta en Marcha | 1w | 2008-10-20 | 2008-10-24 | 102 | 0d |  |  |  |  |
| 104 | 8.7 | Entrega de Trayectorias de Cableado | 1d? | 2008-05-19 | 2008-05-19 |  | 104d | 14d | start no earlier than 2008-05-19 |  |  |
| 105 | 8.8 | Tendido de trayectorias de Cableado | 2w | 2008-06-09 | 2008-06-20 | 104 | 90d |  | start no earlier than 2008-06-09 | Astillero | 80h |
| 106 | 8.9 | Reparaci'on de la Maquina | 12w | 2008-04-07 | 2008-06-27 |  | 85d |  | start no earlier than 2008-04-07 | Astillero | 480h |
| 107 | 9 | **Tablero Local de Babor MEC 71** | 135d? | 2008-04-21 | 2008-10-24 |  | 0d |  |  |  | 80h |
| 108 | 9.1 | Inspección en Sitio | 1w | 2008-04-21 | 2008-04-25 |  | 0d |  | start no earlier than 2008-04-21 |  |  |
| 109 | 9.2 | Aprovación de Planos | 4w | 2008-04-28 | 2008-05-23 | 108 | 0d |  |  |  |  |
| 110 | 9.3 | Fabricación de Equipo | 16w | 2008-05-26 | 2008-09-12 | 109 | 0d |  |  |  |  |
| 111 | 9.4 | Transportación a Guaymas | 4w | 2008-09-15 | 2008-10-10 | 110 | 0d |  |  |  |  |
| 112 | 9.5 | Instalación de Tablero y conexión de señales | 1w | 2008-10-13 | 2008-10-17 | 111 | 0d |  | start no earlier than 2008-07-21 |  |  |
| 113 | 9.6 | Puesta en Marcha | 1w | 2008-10-20 | 2008-10-24 | 112 | 0d |  | start no earlier than 2008-08-04 |  |  |
| 114 | 9.7 | Entrega de Trayectorias de Cableado | 1d? | 2008-05-19 | 2008-05-19 |  | 104d | 14d | start no earlier than 2008-05-19 |  |  |
| 115 | 9.8 | Tendido de trayectorias de Cableado | 2w | 2008-06-09 | 2008-06-20 | 114 | 90d |  | start no earlier than 2008-06-09 | Astillero | 80h |
| 116 | 10 | **Tablero Local Babor SS** | 50d? | 2008-04-21 | 2008-06-27 |  | 85d |  |  |  | 40h |
| 117 | 10.1 | Suministro Gabinete | 8w | 2008-04-21 | 2008-06-13 |  | 85d | 0d | start no earlier than 2008-04-21 |  |  |
| 118 | 10.2 | Instalación de Equipo Tablero SS | 1w | 2008-06-16 | 2008-06-20 | 117 | 85d | 0d | start no earlier than 2008-05-19 |  |  |
| 119 | 10.3 | Instalación de Tablero SS | 2d | 2008-06-23 | 2008-06-24 | 118 | 85d | 0d |  |  |  |
| 120 | 10.4 | Puesta en Marcha | 3d | 2008-06-25 | 2008-06-27 | 119 | 85d |  |  |  |  |
| 121 | 10.5 | Entrega de Trayectorias de Cableado | 1d? | 2008-05-12 | 2008-05-12 |  | 114d | 0d | start no earlier than 2008-05-12 |  |  |
| 122 | 10.6 | Tendido de trayectorias de Cableado | 1w | 2008-05-13 | 2008-05-19 | 121 | 114d |  | start no earlier than 2008-05-05 | Astillero | 40h |

| ID | WBS | Task | Duration | Start | Finish | Predecessors | Total slack | Free slack | Constraint | Resources | Work |
| --- | --- | --- | --- | --- | --- | --- | --- | --- | --- | --- | --- |
| 123 | 11 | **Tablero Local Estribor SS** | 50d? | 2008-04-21 | 2008-06-27 |  | 85d |  |  |  | 40h |
| 124 | 11.1 | Suministro Speed Swicht | 8w | 2008-04-21 | 2008-06-13 |  | 85d | 0d | start no earlier than 2008-04-21 |  |  |
| 125 | 11.2 | Suministro Gabinete | 8w | 2008-04-21 | 2008-06-13 | 124SS | 85d | 0d |  |  |  |
| 126 | 11.3 | Instalación de Equipo Tablero SS | 1w | 2008-06-16 | 2008-06-20 | 125 | 85d | 0d | start no earlier than 2008-05-19 |  |  |
| 127 | 11.4 | Instalación de Tablero SS | 2d | 2008-06-23 | 2008-06-24 | 126 | 85d | 0d |  |  |  |
| 128 | 11.5 | Puesta en Marcha | 3d | 2008-06-25 | 2008-06-27 | 127 | 85d |  |  |  |  |
| 129 | 11.6 | Entrega de Trayectorias de Cableado | 1d? | 2008-05-12 | 2008-05-12 |  | 114d | 0d | start no earlier than 2008-05-12 |  |  |
| 130 | 11.7 | Tendido de trayectorias de Cableado | 1w | 2008-05-13 | 2008-05-19 | 129 | 114d |  | start no earlier than 2008-05-05 | Astillero | 40h |
| 131 | 12 | **Tablero FR 63** | 51d | 2008-04-11 | 2008-06-20 |  | 90d |  |  |  | 160h |
| 132 | 12.1 | Entrega de Material | 8w | 2008-04-14 | 2008-06-06 |  | 90d | 0d | start no earlier than 2008-04-14 |  |  |
| 133 | 12.2 | Fabricación de FR 63 | 1w | 2008-06-09 | 2008-06-13 | 132 | 90d | 0d |  |  |  |
| 134 | 12.3 | Instalación y conexión de Señales | 1w | 2008-06-16 | 2008-06-20 | 133 | 90d |  |  |  |  |
| 135 | 12.4 | Retirar Cable en mal estado de Sensores | 2w | 2008-04-21 | 2008-05-02 |  | 125d |  | start no earlier than 2008-04-21 | Astillero | 80h |
| 136 | 12.5 | Entrega de Trayectorias de Cableado | 1d | 2008-04-11 | 2008-04-11 |  | 130d | 15d | start no earlier than 2008-04-11 |  |  |
| 137 | 12.6 | Tendido de trayectorias de Cableado | 2w | 2008-05-05 | 2008-05-16 | 136 | 115d |  | start no earlier than 2008-05-05 | Astillero | 80h |
| 138 | 13 | **Tablero FR 114** | 63d? | 2008-03-26 | 2008-06-20 |  | 90d |  |  |  | 80h |
| 139 | 13.1 | Entrega de Material | 8w | 2008-04-14 | 2008-06-06 |  | 90d | 0d | start no earlier than 2008-04-14 |  |  |
| 140 | 13.2 | Desinstalaci'on | 1d? | 2008-03-26 | 2008-03-26 |  | 150d | 19d | start no earlier than 2008-03-26 |  |  |
| 141 | 13.3 | Verificaci'on de Cables | 2d | 2008-04-23 | 2008-04-24 | 140 | 131d |  | start no earlier than 2008-04-23 |  |  |
| 142 | 13.4 | Fabricación de FR 114 | 1w | 2008-06-09 | 2008-06-13 | 139 | 90d | 0d |  |  |  |
| 143 | 13.5 | Instalación y conexión de Señales | 1w | 2008-06-16 | 2008-06-20 | 142 | 90d |  |  |  |  |
| 144 | 13.6 | Entrega de Trayectorias de Cableado | 1d | 2008-04-11 | 2008-04-11 |  | 130d | 15d | start no earlier than 2008-04-11 |  |  |
| 145 | 13.7 | Tendido de trayectorias de Cableado | 2w | 2008-05-05 | 2008-05-16 | 144 | 115d |  | start no earlier than 2008-05-05 | Astillero | 80h |
| 146 | 14 | **Tableros de distribución** | 45d | 2008-05-06 | 2008-07-07 |  | 79d |  |  |  |  |
| 147 | 14.1 | Armado de tableros | 5w | 2008-05-06 | 2008-06-09 |  | 79d | 0d | start no earlier than 2008-05-06 |  |  |
| 148 | 14.2 | Traslado de tableros | 4w | 2008-06-10 | 2008-07-07 | 147 | 79d |  |  |  |  |
