# Cronograma buque Sonora 24.03.2008

Schedule from MS Project, 2008-03-25 to 2008-08-15.
Siemens AG

## Calendars

- Standard: Mon-Fri 08:00-12:00, 13:00-17:00; Sat-Sun off.

## Schedule

| ID | WBS | Task | Duration | Start | Finish | Predecessors | Total slack | Free slack | Constraint |
| --- | --- | --- | --- | --- | --- | --- | --- | --- | --- |
| 1 | 1 | **Inicio** | 1d | 2008-03-25 | 2008-03-25 |  | 94d |  |  |
| 2 | 1.1 | Presentación del Plan de Trabajo y del Equipo de Trabajo con el Astillero | 1d | 2008-03-25 | 2008-03-25 |  | 4d | 0d | start no earlier than 2008-03-25 |
| 3 | 2 | **Tablero 2S** | 49d | 2008-03-25 | 2008-05-30 |  | 55d |  |  |
| 4 | 2.1 | Desinstalación de equipos | 2w | 2008-03-25 | 2008-04-07 | 2SS | 4d |  |  |
| 5 | 2.2 | Desmontaje de puertas | 1w | 2008-03-31 | 2008-04-04 |  | 10d | 0d | start no earlier than 2008-03-31 |
| 6 | 2.3 | Fabricación de Puertas | 1w | 2008-04-07 | 2008-04-11 | 5 | 10d | 0d |  |
| 7 | 2.4 | Identificación de cables de fuerza | 2d | 2008-03-31 | 2008-04-01 |  | 8d |  | start no earlier than 2008-03-31 |
| 8 | 2.5 | Verificación de cables en mal estado | 2d | 2008-03-31 | 2008-04-01 | 7SS | 8d |  |  |
| 9 | 2.6 | Verificación de capacidad de barras | 1d | 2008-03-31 | 2008-03-31 | 7SS | 9d |  |  |
| 10 | 2.7 | Suministro de material para el bus | 2d | 2008-04-02 | 2008-04-03 | 8 | 1d | 0d |  |
| 11 | 2.8 | Modificar del Bus de Tablero 2S Instalando barra de cobre de 2 1/2" X 1/4 | 1w | 2008-04-04 | 2008-04-10 | 10 | 1d |  |  |
| 12 | 2.9 | Identificación de Cables de Control y Cedula de Cableado | 1w | 2008-04-14 | 2008-04-18 | 6 | 10d | 0d |  |
| 13 | 2.10 | Instalación de Clemas y canaleta en la placa de Montaje | 1w | 2008-04-21 | 2008-04-25 | 12 | 10d | 0d |  |
| 14 | 2.11 | Prepara Arneces en puerta de Gen 3, Gen 2 y Enlace | 1w | 2008-04-21 | 2008-04-25 | 13SS | 10d |  |  |
| 15 | 2.12 | Instalación de Interruptores electromagneticos. | 2d | 2008-05-05 | 2008-05-06 |  | 25d | 0d | start no earlier than 2008-05-05 |
| 16 | 2.13 | Conexión de electros a Bus | 3d | 2008-05-07 | 2008-05-09 | 15 | 25d | 0d |  |
| 17 | 2.14 | Instalación de equipos en puertas | 1w | 2008-05-12 | 2008-05-16 | 16 | 25d | 0d |  |
| 18 | 2.15 | Montaje de equipos en celdas de control G2 | 2w | 2008-05-19 | 2008-05-30 | 17 | 25d | 0d |  |
| 19 | 2.16 | Montaje de equipos en celdas de control G3 | 2w | 2008-05-19 | 2008-05-30 | 18SS | 25d | 0d |  |
| 20 | 2.17 | Montaje de equipos en celdas de control Enlace 2 | 2w | 2008-05-19 | 2008-05-30 | 19SS | 25d |  |  |
| 21 | 2.18 | Alambrado de celda de G2 | 1w | 2008-05-26 | 2008-05-30 |  | 25d | 0d | start no earlier than 2008-05-26 |
| 22 | 2.19 | Alambrado de celda de G3 | 1w | 2008-05-26 | 2008-05-30 | 21SS | 25d | 0d |  |
| 23 | 2.20 | Alambrado de celda Enlace 2 | 1w | 2008-05-26 | 2008-05-30 | 22SS | 25d | 2d |  |
| 24 | 2.21 | Puesta en Marcha 2S | 3d | 2008-05-28 | 2008-05-30 | 23SS | 25d |  | start no earlier than 2008-05-28 |

| ID | WBS | Task | Duration | Start | Finish | Predecessors | Total slack | Free slack | Constraint |
| --- | --- | --- | --- | --- | --- | --- | --- | --- | --- |
| 25 | 3 | **Tablero 1S** | 75d | 2008-04-14 | 2008-07-25 |  | 15d |  |  |
| 26 | 3.1 | Desinstalación de equipos | 1w | 2008-04-14 | 2008-04-18 |  | 30d | 0d | start no earlier than 2008-04-14 |
| 27 | 3.2 | Desmontaje de tablero existente | 1w | 2008-04-21 | 2008-04-25 | 26 | 50d |  |  |
| 28 | 3.3 | Identificación de cables de fuerza | 2d | 2008-04-14 | 2008-04-15 | 26SS | 58d | 0d |  |
| 29 | 3.4 | Identificación de cables de control. | 2d | 2008-04-14 | 2008-04-15 | 28SS | 58d | 0d |  |
| 30 | 3.5 | Verificación de cables en mal estado | 2d | 2008-04-14 | 2008-04-15 | 29SS | 58d |  | start no earlier than 2008-04-14 |
| 31 | 3.6 | Elaboración de Cedula de Cableado | 1w | 2008-04-21 | 2008-04-25 |  | 50d |  | start no earlier than 2008-04-21 |
| 32 | 3.7 | Armado de celda G1 | 3w | 2008-05-19 | 2008-06-06 |  | 5d | 0d | start no earlier than 2008-05-19 |
| 33 | 3.8 | Armado de celda Enlace | 3w | 2008-05-19 | 2008-06-06 | 32SS | 5d | 0d |  |
| 34 | 3.9 | Armado de celda SL | 3w | 2008-05-19 | 2008-06-06 | 33SS | 5d | 0d |  |
| 35 | 3.10 | Armado de celdas de distribución | 3w | 2008-05-19 | 2008-06-06 | 34SS | 5d | 0d |  |
| 36 | 3.11 | Translado del Tablero 1S | 4w | 2008-06-09 | 2008-07-04 | 35 | 5d | 0d |  |
| 37 | 3.12 | Montaje del Tablero 1S Nuevo. | 1w | 2008-07-07 | 2008-07-11 | 36 | 5d | 0d |  |
| 38 | 3.13 | Alambrado de celda a G1 | 1w | 2008-07-14 | 2008-07-18 | 37 | 5d |  |  |
| 39 | 3.14 | Alambrado de celda a SL | 1w | 2008-07-14 | 2008-07-18 | 37 | 5d |  |  |
| 40 | 3.15 | Alambrado de celda Enlace 1 a Enlace 2 | 1w | 2008-07-14 | 2008-07-18 | 37 | 5d | 0d |  |
| 41 | 3.16 | Puesta en Marcha 1S | 1w | 2008-07-21 | 2008-07-25 | 40 | 5d |  |  |
| 42 | 4 | **Consolas Cuarto de Control** | 75d | 2008-04-21 | 2008-08-01 |  | 10d |  |  |
| 43 | 4.1 | Desinstalación de equipos | 1w | 2008-04-21 | 2008-04-25 |  | 68d | 0d | start no earlier than 2008-04-21 |
| 44 | 4.2 | Identificación de cables de control. | 1w | 2008-04-21 | 2008-04-25 | 43SS | 68d | 0d |  |
| 45 | 4.3 | Elaborar Cedula de Cableado | 1w | 2008-04-21 | 2008-04-25 | 44SS | 68d | 0d |  |
| 46 | 4.4 | Verificación del estado fisico de los cables | 1w | 2008-04-21 | 2008-04-25 | 45SS | 68d | 0d |  |
| 47 | 4.5 | Desmontaje de la Consola de Control | 2d | 2008-04-28 | 2008-04-29 | 46 | 68d |  |  |
| 48 | 4.6 | Aramado de Consolas PMA | 3w | 2008-05-19 | 2008-06-06 |  | 10d | 0d | start no earlier than 2008-05-19 |
| 49 | 4.7 | Aramado de Consolas IMAC | 3w | 2008-05-19 | 2008-06-06 | 48SS | 10d | 0d |  |
| 50 | 4.8 | Aramado de Consolas MEC | 3w | 2008-05-19 | 2008-06-06 | 49SS | 10d | 0d |  |
| 51 | 4.9 | Translado de la consola | 4w | 2008-06-09 | 2008-07-04 | 50 | 10d | 0d |  |
| 52 | 4.10 | Instalación de Consolas | 2w | 2008-07-07 | 2008-07-18 | 51 | 10d | 0d |  |
| 53 | 4.11 | Puesta en Marcha IMAC | 2w | 2008-07-21 | 2008-08-01 | 52 | 10d | 0d |  |
| 54 | 4.12 | Puesta en Marcha PMA | 1w | 2008-07-21 | 2008-07-25 | 53SS | 5d |  |  |

| ID | WBS | Task | Duration | Start | Finish | Predecessors | Total slack | Free slack | Constraint |
| --- | --- | --- | --- | --- | --- | --- | --- | --- | --- |
| 55 | 5 | **Consola Puente de Mando.** | 70d | 2008-04-14 | 2008-07-18 |  | 20d |  |  |
| 56 | 5.1 | Desinstalación de equipos | 1w | 2008-06-09 | 2008-06-13 |  | 35d |  | start no earlier than 2008-06-09 |
| 57 | 5.2 | Identificación de cables de control. | 1w | 2008-04-14 | 2008-04-18 |  | 70d | 0d | start no earlier than 2008-04-14 |
| 58 | 5.3 | Verificación del estado fisico de los cables | 1w | 2008-04-14 | 2008-04-18 | 57SS | 70d | 0d |  |
| 59 | 5.4 | Elaboración de Cedula de Cableado | 1w | 2008-04-21 | 2008-04-25 | 58 | 70d |  |  |
| 60 | 5.5 | Desmontaje de placas frontales y placas pupitre | 2d | 2008-06-16 | 2008-06-17 | 56 | 28d | 0d |  |
| 61 | 5.6 | Fabricación de nuevas placas con saques de equipos MEC | 1w | 2008-06-18 | 2008-06-24 | 60 | 28d |  |  |
| 62 | 5.7 | Instalación de Equipos IMAC y MEC71 | 1w | 2008-06-30 | 2008-07-04 |  | 10d | 0d | start no earlier than 2008-06-30 |
| 63 | 5.8 | Puesta en Marcha IMAC, MEC | 2w | 2008-07-07 | 2008-07-18 | 62 | 10d |  |  |
| 64 | 6 | **Tablero Local de Estribor MP 377A** | 65d | 2008-04-21 | 2008-07-18 |  | 20d |  |  |
| 65 | 6.1 | Desinstalación de equipos | 1w | 2008-04-21 | 2008-04-25 |  | 70d |  | start no earlier than 2008-04-21 |
| 66 | 6.2 | Desmontaje del Tablero | 1w | 2008-04-21 | 2008-04-25 | 65SS | 65d | 0d |  |
| 67 | 6.3 | Identificación de Cable y Cedula de Cableado | 1w | 2008-04-28 | 2008-05-02 | 66 | 65d | 0d |  |
| 68 | 6.4 | Separación señales IMAC MEC | 1w | 2008-04-28 | 2008-05-02 | 67SS | 65d |  |  |
| 69 | 6.5 | Armado de Tablero | 2w | 2008-05-12 | 2008-05-23 |  | 50d |  | start no earlier than 2008-05-12 |
| 70 | 6.6 | Translado del Tablero | 4w | 2008-06-09 | 2008-07-04 |  | 20d |  | start no earlier than 2008-06-09 |
| 71 | 6.7 | Instalación de Tablero y conexión de señales | 2w | 2008-07-07 | 2008-07-18 |  | 10d |  | start no earlier than 2008-07-07 |
| 72 | 7 | **Tablero Loca deBabor MP 377A** | 65d | 2008-04-21 | 2008-07-18 |  | 20d |  |  |
| 73 | 7.1 | Desinstalación de equipos | 1w | 2008-04-21 | 2008-04-25 |  | 65d | 0d | start no earlier than 2008-04-21 |
| 74 | 7.2 | Desmontaje del Tablero. | 1w | 2008-04-21 | 2008-04-25 | 73SS | 65d | 0d | start no earlier than 2008-04-21 |
| 75 | 7.3 | Identificación de Cable y Cedula de Cableado | 1w | 2008-04-28 | 2008-05-02 | 74 | 65d | 0d | start no earlier than 2008-04-28 |
| 76 | 7.4 | Separación señales IMAC MEC | 1w | 2008-04-28 | 2008-05-02 | 75SS | 65d |  | start no earlier than 2008-04-28 |
| 77 | 7.5 | Armado de Tablero | 2w | 2008-05-12 | 2008-05-23 |  | 50d |  | start no earlier than 2008-05-12 |
| 78 | 7.6 | Translado de Tablero | 4w | 2008-06-09 | 2008-07-04 |  | 20d |  | start no earlier than 2008-06-09 |
| 79 | 7.7 | Instalación de Tablero y conexión de señales | 2w | 2008-07-07 | 2008-07-18 |  | 10d |  | start no earlier than 2008-07-07 |

| ID | WBS | Task | Duration | Start | Finish | Predecessors | Total slack | Free slack | Constraint |
| --- | --- | --- | --- | --- | --- | --- | --- | --- | --- |
| 80 | 8 | **Tablero Local de Estribor MEC 71** | 20d | 2008-07-21 | 2008-08-15 |  | 0d |  |  |
| 81 | 8.1 | Instalación de Tablero y conexión de señales | 2w | 2008-07-21 | 2008-08-01 |  | 0d |  | start no earlier than 2008-07-21 |
| 82 | 8.2 | Puesta en Marcha | 2w | 2008-08-04 | 2008-08-15 | 81 | 0d |  |  |
| 83 | 9 | **Tablero Local de Babor MEC 71** | 20d | 2008-07-21 | 2008-08-15 |  | 0d |  |  |
| 84 | 9.1 | Instalación de Tablero y conexión de señales | 2w | 2008-07-21 | 2008-08-01 |  | 0d |  | start no earlier than 2008-07-21 |
| 85 | 9.2 | Puesta en Marcha | 2w | 2008-08-04 | 2008-08-15 | 84 | 0d |  | start no earlier than 2008-08-04 |
| 86 | 10 | **Tablero Local Babor SS** | 5d | 2008-07-14 | 2008-07-18 |  | 20d |  |  |
| 87 | 10.1 | Instalación de Equipo Tablero SS | 1w | 2008-07-14 | 2008-07-18 |  | 20d | 0d | start no earlier than 2008-07-14 |
| 88 | 10.2 | Instalación de Tablero SS | 1w | 2008-07-14 | 2008-07-18 | 87SS | 20d | 0d |  |
| 89 | 10.3 | Puesta en Marcha | 1w | 2008-07-14 | 2008-07-18 | 88SS | 20d |  |  |
| 90 | 11 | **Tablero Local Estribor SS** | 5d | 2008-07-21 | 2008-07-25 |  | 15d |  |  |
| 91 | 11.1 | Instalación de Equipo Tablero SS | 1w | 2008-07-21 | 2008-07-25 |  | 15d | 0d | start no earlier than 2008-07-21 |
| 92 | 11.2 | Instalación de Tablero SS | 1w | 2008-07-21 | 2008-07-25 | 91SS | 15d | 0d |  |
| 93 | 11.3 | Puesta en Marcha | 1w | 2008-07-21 | 2008-07-25 | 92SS | 15d |  |  |
| 94 | 12 | **Tablero FR 63** | 45d | 2008-05-12 | 2008-07-11 |  | 25d |  |  |
| 95 | 12.1 | Fabricación de FR 63 | 1w | 2008-05-12 | 2008-05-16 |  | 60d | 0d | start no earlier than 2008-05-12 |
| 96 | 12.2 | Traslado FR 63 | 4w | 2008-06-09 | 2008-07-04 |  | 25d | 0d | start no earlier than 2008-06-09 |
| 97 | 12.3 | Instalación y conexión de Señales | 1w | 2008-07-07 | 2008-07-11 | 96 | 25d |  |  |
| 98 | 13 | **Tablero FR 114** | 45d | 2008-05-12 | 2008-07-11 |  | 25d |  |  |
| 99 | 13.1 | Fabricación de FR 114 | 1w | 2008-05-12 | 2008-05-16 |  | 65d |  | start no earlier than 2008-05-12 |
| 100 | 13.2 | Traslado FR 63 | 4w | 2008-06-09 | 2008-07-04 |  | 25d | 0d | start no earlier than 2008-06-09 |
| 101 | 13.3 | Instalación y conexión de Señales | 1w | 2008-07-07 | 2008-07-11 | 100 | 25d |  |  |
| 102 | 14 | **Tableros de distribución** | 45d | 2008-05-06 | 2008-07-07 |  | 29d |  |  |
| 103 | 14.1 | Armado de tableros | 5w | 2008-05-06 | 2008-06-09 |  | 29d | 0d | start no earlier than 2008-05-06 |
| 104 | 14.2 | Traslado de tableros | 4w | 2008-06-10 | 2008-07-07 | 103 | 29d |  |  |
